# ERS_Project_Schedule_20040804

How a schedule from MS Project changed from version to version. A marks actual dates.

## Version 1 (saved 2004-07-30, file ERS_Project_Schedule_20040805.mpp)

| ID | WBS | Task | Duration | Start | Finish | Predecessors | Complete | Total float | Constraint |
| --- | --- | --- | --- | --- | --- | --- | --- | --- | --- |
| 1 | 1 | **Start-up** | 184d? | 2004-03-28 A | 2004-12-09 |  | 33% | 309d |  |
| 2 |  | Identify Project Manager | 43d | 2004-03-28 A | 2004-05-26 A |  | 100% |  | finish no earlier than 2003-11-30 |
| 3 |  | Identify Liaison | 112d | 2004-03-28 A | 2004-08-31 |  | 10% | 381d | finish no earlier than 2004-08-31 |
| 4 |  | Identify other staff for start | 85d | 2004-04-26 A | 2004-08-20 |  | 32% | 388d | finish no earlier than 2004-08-20 |
| 6 |  | ERS Management Group Meetings | 116d? | 2004-07-01 A | 2004-12-09 |  | 22% | 309d |  |
| 17 |  | Requirements Committee Meetings | 115d? | 2004-07-01 A | 2004-12-08 |  | 25% | 310d |  |
| 27 |  | Technical Advisory Group Meetings | 1d? | 2004-08-03 | 2004-08-03 |  |  | 401d |  |
| 31 | 2 | **Architecture/Design** | 90d | 2004-07-19 A | 2004-11-19 |  |  | 323d |  |
| 32 | 2.1 | **Application Code Design** | 32d | 2004-07-19 A | 2004-08-31 |  | 3% | 381d |  |
| 33 |  | PAR Processing | 25d | 2004-07-19 A | 2004-08-20 |  | 5% | 388d | start no earlier than 2004-07-19 |
| 34 |  | Security and roles processing | 15d | 2004-08-11 | 2004-08-31 | 33SS+17d |  | 381d | start no earlier than 2004-07-26 |
| 35 | 2.2 | **Database Design** | 45d | 2004-08-09 | 2004-10-08 |  |  | 353d |  |
| 36 |  | Data Element definition | 15d | 2004-08-09 | 2004-08-27 |  |  | 353d | start no earlier than 2004-08-09 |
| 37 |  | Data schema design | 30d | 2004-08-30 | 2004-10-08 | 36 |  | 353d |  |
| 38 | 2.3 | **Presentation Design - User** | 70d | 2004-08-16 | 2004-11-19 |  |  | 323d |  |
| 39 |  | Presentation user initial design | 35d | 2004-08-16 | 2004-10-01 |  |  | 323d | start no earlier than 2004-08-16 |
| 40 |  | Presentation user revised design | 35d | 2004-10-04 | 2004-11-19 | 39 |  | 323d |  |
| 41 | 2.4 | **Presentation Design - Administration** | 58d | 2004-09-01 | 2004-11-19 | 38SS+10d |  | 323d |  |
| 42 |  | Presentation Admin - initial design | 20d | 2004-09-01 | 2004-09-28 | 39SS+5d |  | 323d | start no earlier than 2004-09-01 |
| 43 |  | Presentation Admin - revised design | 38d | 2004-09-29 | 2004-11-19 | 42 |  | 323d |  |
| 44 | 2.5 | **Data Interfaces** | 53d | 2004-08-09 | 2004-10-20 |  |  | 345d |  |
| 45 |  | Financial Data | 30d | 2004-08-09 | 2004-09-17 | 33SS+15d |  | 345d |  |
| 46 |  | Security and E-mail Systems | 25d | 2004-09-16 | 2004-10-20 | 45FS-2d |  | 345d |  |
| 48 | 3 | **Development** | 350d | 2004-09-06 | 2006-01-06 |  |  | 28d |  |
| 49 | 3.1 | **Data Interfaces** | 150d | 2004-09-27 | 2005-04-22 |  |  | 213d |  |
| 50 |  | Initial Data Load | 320h | 2004-09-27 | 2004-11-19 |  |  | 323d | start no earlier than 2004-09-26 |
| 51 |  | Payroll/Personnel System (PPS) | 200h | 2004-10-21 | 2004-11-24 |  |  | 320d |  |
| 52 |  | Financial Systems | 200h | 2004-11-25 | 2004-12-29 |  |  | 295d |  |
| 53 |  | Contracts & Grants | 200h | 2004-12-16 | 2005-01-19 |  |  | 280d |  |
| 54 |  | Cost Sharing | 320h | 2005-01-20 | 2005-03-16 |  |  | 240d |  |
| 55 |  | Authentication | 200h | 2004-11-01 | 2004-12-03 |  |  | 313d | start no earlier than 2004-10-31 |
| 56 |  | Authorization | 200h | 2004-12-06 | 2005-01-07 |  |  | 288d | start no earlier than 2004-12-05 |
| 57 |  | Email | 216h | 2005-03-17 | 2005-04-22 |  |  | 213d |  |
| 58 |  | Web Presentation | 640h | 2004-09-06 | 2004-12-24 |  |  | 298d | start no earlier than 2004-09-05 |
| 59 |  | Authorization Rules | 480h | 2005-01-03 | 2005-03-25 |  |  | 233d | start no earlier than 2005-01-02 |
| 60 |  | Authorizaton Administration | 480h | 2005-01-03 | 2005-03-25 |  |  | 233d | start no earlier than 2005-01-02 |
| 61 |  | Web Navigation | 213.33h | 2004-12-27 | 2005-02-01 |  |  | 271.33d | start no earlier than 2004-12-26 |
| 62 | 3.6 | **Effort Report Generation** | 205d | 2005-01-03 | 2005-10-14 |  |  | 88d |  |
| 63 |  | Standard Report | 480h | 2005-01-03 | 2005-03-25 |  |  | 233d | start no earlier than 2005-01-02 |
| 64 |  | Exception | 480h | 2005-04-14 | 2005-07-06 |  |  | 160d |  |
| 65 |  | Reissuance | 240h | 2005-09-05 | 2005-10-14 |  |  | 88d |  |
| 66 |  | Notification Creation & Distribution | 320h | 2005-04-04 | 2005-05-27 |  |  | 188d | start no earlier than 2005-04-03 |
| 67 |  | Effort Report Search/Selection | 480h | 2005-01-31 | 2005-04-22 |  |  | 213d | start no earlier than 2005-01-30 |
| 68 |  | Online Effort Report Data Changes | 160h | 2005-07-07 | 2005-08-03 |  |  | 140d |  |
| 69 |  | Online Certifications | 160h | 2005-08-04 | 2005-08-31 |  |  | 120d |  |
| 70 |  | Multiple Certifications | 320h | 2005-09-01 | 2005-10-26 |  |  | 80d |  |
| 71 |  | Online Exception Data Collection/Modification | 480h | 2005-05-02 | 2005-07-22 |  |  | 148d | start no earlier than 2005-05-01 |
| 72 |  | Edits | 960h | 2005-03-28 | 2005-09-09 |  |  | 113d | start no earlier than 2005-03-27 |
| 73 |  | Reminders | 200h | 2005-06-27 | 2005-07-29 |  |  | 143d | start no earlier than 2005-06-26 |
| 74 |  | Compliance Monitoring Tools* | 640h | 2005-05-19 | 2005-09-07 |  |  | 115d |  |
| 75 |  | Control/Audit Reports* | 480h | 2005-08-29 | 2005-11-18 |  |  | 63d | start no earlier than 2005-08-28 |
| 76 |  | General Reporting* | 960h | 2005-07-25 | 2006-01-06 |  |  | 28d | start no earlier than 2005-07-24 |
| 77 |  | Ad Hoc Reporting* | 960h | 2005-07-04 | 2005-12-16 |  |  | 43d | start no earlier than 2005-07-03 |
| 79 | 4 | **Testing** | 100d | 2005-08-22 | 2006-01-06 |  |  | 28d |  |
| 80 |  | Application Testing | 664h | 2005-08-22 | 2005-12-14 |  |  | 45d | start no earlier than 2005-08-21 |
| 81 |  | Load/Stress Testing | 320h | 2005-11-14 | 2006-01-06 |  |  | 28d | start no earlier than 2005-11-13 |
| 83 | 5 | **Deployment (Release to Campuses)** | 107d | 2005-09-08 | 2006-02-03 |  |  | 8d |  |
| 84 |  | Documentation | 544h | 2005-09-08 | 2005-12-12 |  |  | 47d |  |
| 85 |  | Technical Training | 320h | 2005-11-03 | 2005-12-28 |  |  | 35d |  |
| 86 |  | Deployment (Release) Packaging | 160h | 2006-01-09 | 2006-02-03 |  |  | 8d | start no earlier than 2006-01-08 |
| 88 | 6 | **Project Management** | 428d | 2004-06-28 A | 2006-02-15 |  | 4% | 0d |  |
| 89 |  | Technical Project Management | 3400h | 2004-07-01 A | 2006-02-15 |  | 4% | 0d |  |
| 90 |  | Campus Coordination | 3322.5h | 2004-06-28 A | 2006-01-30 |  | 5% | 12.69d | start no earlier than 2004-06-27 |
| 92 | 7 | **Functional Preparation** | 436d? | 2004-05-04 A | 2006-01-03 |  | 10% | 31d |  |
| 93 |  | Policy/Guideline/Procedure Review | 108d | 2004-05-04 A | 2004-09-30 |  | 50% | 359d | start no earlier than 2004-05-04 |
| 94 |  | Preparation of Policy Issues for Universitywide Review | 22d? | 2004-09-30 | 2004-10-31 |  |  | 338d | finish no earlier than 2004-10-31 |
| 95 |  | Universitywide Policy Review | 66d? | 2004-11-01 | 2005-01-31 |  |  | 272d | finish no earlier than 2005-01-31 |
| 96 |  | End-User Training Strategy | 80d | 2004-05-10 A | 2004-08-27 |  | 10% | 383d | start no earlier than 2004-05-09 |
| 97 |  | Common End-User Training Development | 347d | 2004-09-06 | 2006-01-03 |  |  | 31d | start no earlier than 2004-09-05 |
| 99 | 8 | **PPS Activities (Finish Dates Tentative)** | 314d? | 2004-03-02 A | 2005-05-15 |  | 52% | 198d |  |

| ID | WBS | Task | Duration | Start | Finish | Complete | Total float | Constraint |
| --- | --- | --- | --- | --- | --- | --- | --- | --- |
| 100 |  | Effort Percent Time | 50d | 2004-05-24 A | 2004-07-31 A | 100% |  | finish no earlier than 2004-07-31 |
| 101 | 8.2 | **NIH Salary Cap** | 314d? | 2004-03-02 A | 2005-05-15 | 40% | 198d |  |
| 102 |  | Requirements | 109d? | 2004-03-02 A | 2004-07-31 | 75% | 403d | finish no earlier than 2004-07-31 |
| 103 |  | Base PPS Modifications | 95d? | 2005-01-03 | 2005-05-15 |  | 198d | finish no earlier than 2005-05-15 |

## Version 2 (saved 2004-09-14, file ERS_Project_Schedule_20040916.mpp)

Last finish stays 2006-02-15. Complete tasks 2 → 3.

Added:

| ID | Task | Duration | Start | Finish | Predecessors | Constraint |
| --- | --- | --- | --- | --- | --- | --- |
| 38 | Hire Data Base Designer | 11d? | 2004-09-13 A | 2004-09-27 |  | finish no earlier than 2004-09-27 |
| 40 | Define Batch extract schema | 20d | 2004-10-26 | 2004-11-22 | 39 |  |
| 43 | Hire Graphics consultant | 11d | 2004-09-27 | 2004-10-11 |  | finish no earlier than 2004-10-11 |
| 52 | PPS/PAR System Extracts | 20d | 2004-11-23 | 2004-12-20 | 38, 39, 40 |  |
| 107 | PPS Release 1591 available for campus install with effort percent time | 1d? | 2004-07-26 A | 2004-07-26 A |  | start no earlier than 2004-08-23 |

Changed:

| ID | Task | Start | Finish | Duration | Complete | Total float | Predecessors | Other |
| --- | --- | --- | --- | --- | --- | --- | --- | --- |
| 1 | **Start-up** |  | 2004-12-09 → 2004-08-31 (-100d) | 184d? → 112d | 33% → 34% | 309d → 381d |  |  |
| 6 | ERS Management Group Meetings |  |  |  | 22% → 44% |  |  |  |
| 17 | Requirements Committee Meetings |  |  |  | 25% → 50% |  |  |  |
| 27 | Technical Advisory Group Meetings | 2004-08-03 A | 2004-08-03 → 2004-10-05 (+63d) | 1d? → 46d? | 0% → 50% | 401d → 356d |  |  |
| 33 | **Architecture/Design** |  | 2004-11-19 → 2005-02-21 (+94d) | 90d → 155.5d? | 0% → 12% | 323d → 257.5d |  |  |
| 34 | **Application Code Design** |  | 2004-08-31 → 2004-09-24 (+24d) | 32d → 50d | 3% → 48% | 381d → 363d |  |  |
| 35 | PAR Processing |  | 2004-08-20 → 2004-09-24 (+35d) | 25d → 50d | 5% → 35% | 388d → 294.5d |  |  |
| 36 | Security and roles processing | 2004-08-11 A | 2004-08-31 → 2004-09-21 (+21d) | 15d → 30d | 0% → 70% | 381d → 366d |  |  |
| 37 | **Database Design** | 2004-08-09 → 2004-09-13 A (+35d) | 2004-10-08 → 2005-01-03 (+87d) | 45d → 81d? | 0% → 2% | 353d → 292d |  |  |
| 39 | Data Element definition | 2004-08-09 → 2004-09-28 (+50d) | 2004-08-27 → 2004-10-25 (+59d) | 15d → 20d |  | 353d → 292d | none → 38 |  |
| 41 | Data schema design | 2004-08-30 → 2004-11-23 (+85d) | 2004-10-08 → 2005-01-03 (+87d) |  |  | 353d → 292d | 39 → 40 |  |
| 42 | **Presentation Design - User** | 2004-08-16 A | 2004-11-19 → 2005-01-12 (+54d) | 70d → 107.5d | 0% → 4% | 323d → 178.83d |  |  |
| 44 | Presentation user initial design | 2004-08-16 A | 2004-10-01 → 2004-11-24 (+54d) |  | 0% → 10% | 323d → 178.83d | none → 43 |  |
| 45 | Presentation user revised design | 2004-10-04 → 2004-11-24 (+51d) | 2004-11-19 → 2005-01-12 (+54d) |  |  | 323d → 178.83d |  |  |
| 46 | **Presentation Design - Administration** | 2004-09-01 → 2004-12-01 (+91d) | 2004-11-19 → 2005-02-21 (+94d) |  |  | 323d → 257.5d |  |  |
| 47 | Presentation Admin - initial design | 2004-09-01 → 2004-12-01 (+91d) | 2004-09-28 → 2004-12-29 (+92d) |  |  | 323d → 257.5d | 44SS+5d → 44FS+5d, 43 |  |
| 48 | Presentation Admin - revised design | 2004-09-29 → 2004-12-29 (+91d) | 2004-11-19 → 2005-02-21 (+94d) |  |  | 323d → 257.5d |  |  |
| 49 | **Data Interfaces** | 2004-08-09 → 2004-09-13 A (+35d) | 2004-10-20 → 2004-12-20 (+61d) | 53d → 71d | 0% → 2% | 345d → 302d |  |  |
| 50 | Financial Data | 2004-08-09 → 2004-09-13 A (+35d) | 2004-09-17 → 2004-11-05 (+49d) |  | 0% → 5% | 345d → 308.5d | 35SS+15d → 35, 38 |  |
| 51 | Security and E-mail Systems | 2004-09-16 → 2004-11-05 (+50d) | 2004-10-20 → 2004-12-10 (+51d) |  |  | 345d → 308.5d | 50FS-2d → 50 |  |
| 54 | **Development** | 2004-09-06 → 2004-11-01 (+56d) |  | 350d → 310d |  |  |  |  |
| 55 | **Data Interfaces** | 2004-09-27 → 2004-11-01 (+35d) |  | 150d → 125d |  |  |  |  |
| 56 | Initial Data Load | 2004-09-27 → 2004-12-07 (+71d) | 2004-11-19 → 2005-01-31 (+73d) |  |  | 323d → 272d | none → 52SS+10d, 40 |  |
| 57 | Payroll/Personnel System (PPS) | 2004-10-21 → 2004-11-30 (+40d) | 2004-11-24 → 2005-01-03 (+40d) |  |  | 320d → 292d | none → 52SS+5d |  |
| 64 | Web Presentation | 2004-09-06 → 2005-01-12 (+128d) | 2004-12-24 → 2005-05-04 (+131d) |  |  | 298d → 178.83d | none → 43, 45 |  |
| 67 | Web Navigation | 2004-12-27 → 2005-05-04 (+128d) | 2005-02-01 → 2005-06-10 (+129d) |  |  | 271.33d → 178.83d | none → 64 |  |
| 100 | Preparation of Policy Issues for Universitywide Review | 2004-09-30 A |  |  | 0% → 20% |  |  |  |
| 102 | End-User Training Strategy |  | 2004-08-27 → 2004-10-01 (+35d) | 80d → 105d | 10% → 8% | 383d → 358d |  | constraint start no earlier than 2004-05-09 → finish no earlier than 2004-10-01 |
| 105 | **PPS Activities (Finish Dates Tentative)** |  |  |  | 52% → 41% |  |  |  |
| 106 | Effort Percent Time |  | 2004-07-31 A → 2004-07-23 A (-8d) | 50d → 45d |  |  |  |  |
| 108 | **NIH Salary Cap** |  |  |  | 40% → 30% |  |  |  |
| 109 | Requirements |  | 2004-07-31 → 2004-10-29 (+90d) | 109d? → 174d? | 75% → 47% | 403d → 338d |  | constraint finish no earlier than 2004-07-31 → finish no earlier than 2004-10-29 |
